# Short Film Project

Schedule from MS Project, 2021-04-02 to 2021-12-29, status date 2021-08-25, costs in $, A marks actual dates.
Film Schedule
Industrial Smoke and Mirrors
Includes pre-production, production, and post-production tasks.

## Calendars

- Standard: Mon-Fri 10:00-13:00, 14:00-19:00; Sat-Sun off.
- Night Shift: Mon 23:00-24:00; Tue-Fri 00:00-03:00, 04:00-08:00, 23:00-24:00; Sat 00:00-03:00, 04:00-08:00; Sun off.
- Evening Shoot: Mon-Fri 19:00-24:00; Sat-Sun off.

## Resources

| Resource | Group | Unit | Rate | Cost per use | Notes |
| --- | --- | --- | --- | --- | --- |
| Clair Hector | Production |  | 20 |  | Clair attending west coast film festival May 21 and 22, unavailable to work on project |
| Electrician | Crew |  | 22 |  |  |
| Jan Miksovsky | Production |  | 18.75 |  |  |
| Scott Cooper | Production |  | 19.37 |  |  |
| Jo Brown | Production |  | 18.75 |  |  |
| Kim Yoshida | Production |  | 9.4 |  |  |
| Peter Kelly | Production |  | 16.75 |  |  |
| John Thorson | Production |  | 15.5 |  |  |
| 5000 Watt Light | Equipment |  | 2.5 |  |  |
| Dolly | Equipment |  |  |  |  |
| Crane | Equipment |  |  |  |  |
| Editing Lab | Film and Lab |  | 25 | 25 |  |
| 16 mm Film | Film and Lab | Feet | 0.2 |  |  |
| 16 mm Camera | Equipment |  | 6.25 |  |  |
| Anne L. Paper | Talent |  | 9.38 |  |  |
| Daniel Penn | Talent |  | 9.38 |  |  |
| David Campbell | Talent |  | 9.38 |  |  |
| Doug Hampton | Production |  | 13 |  |  |
| Eric Lang | Production |  | 15.5 |  |  |
| Eric Miller | Talent |  | 9.38 |  |  |
| Florian Voss | Production |  | 22 |  |  |
| Frank Lee | Crew |  | 14 |  |  |
| Jim Hance | Talent |  | 9.38 |  |  |
| Johnathan Perrera | Production |  | 22 |  |  |
| Joseph Matthews | Talent |  | 9.38 |  |  |
| Joshua Randall | Talent |  | 12 |  |  |
| Kathryn Wilson | Production |  | 5 | 100 |  |
| Keith Harris | Crew |  | 14 |  |  |
| Linda Kobara | Production |  | 24 |  |  |
| Lisa Garmaise | Production |  | 9 |  |  |
| Mark Hassall | Production |  | 23.75 |  |  |
| Max Benson | Crew |  | 24 |  |  |
| Megan Sherman | Crew |  | 18 |  |  |
| Megan’s 16 mm camera | Equipment |  |  |  |  |
| Michael Patten | Production |  | 17.5 |  |  |
| Pat Kirkland | Production |  | 5.62 |  |  |
| Paul Born | Production |  | 25 |  |  |
| Richard Lum | Production |  | 15.62 |  |  |
| Salman Mughal | Production |  | 18 |  |  |
| Sue Jackson | Talent |  | 9.38 |  |  |
| Ted Bremer | Crew |  | 14 |  |  |
| Tim O'Brien | Crew |  | 14 |  |  |

## Schedule

| ID | WBS | Task | Type | Duration | Start | Finish | Predecessors | Complete | Remaining | Baseline start | Baseline finish | Baseline duration | Baseline 1 start | Baseline 1 finish | Total slack | Constraint | Deadline | Calendar | Resources | Work | Actual work | Cost | Baseline cost | Actual cost | Cast | Location |
| --- | --- | --- | --- | --- | --- | --- | --- | --- | --- | --- | --- | --- | --- | --- | --- | --- | --- | --- | --- | --- | --- | --- | --- | --- | --- | --- |
| 1 | 1 | **Pre-Production** |  | 71d | 2021-04-02 A | 2021-07-10 A |  | 100% |  | 2021-04-02 | 2021-07-04 | 67.61d | 2021-04-02 | 2021-07-04 |  |  |  |  |  | 1636.91h | 1636.91h | 29,356.13 | 28,749.32 | 29,356.13 |  |  |
| 2 | 1.1 | Review script |  | 2w | 2021-04-02 A | 2021-04-16 A |  | 100% |  | 2021-04-02 | 2021-04-16 | 2w | 2021-04-02 | 2021-04-16 |  |  |  |  | Scott Cooper; Clair Hector | 112h | 112h | 2,205 | 2,205 | 2,205 |  |  |
| 3 | 1.2 | Develop script breakdown and schedule |  | 0.73w | 2021-04-16 A | 2021-04-21 A | 2 | 100% |  | 2021-04-16 | 2021-04-19 | 0.73w | 2021-04-16 | 2021-04-19 |  |  |  |  | Scott Cooper; John Thorson [75%]; Johnathan Perrera | 80h | 80h | 1,541.82 | 1,541.82 | 1,541.82 |  |  |
| 4 | 1.3 | Develop production boards |  | 21.5d | 2021-04-19 A | 2021-05-20 A | 3 | 100% |  | 2021-04-19 | 2021-05-23 | 21.5d | 2021-04-19 | 2021-05-23 |  |  |  |  | Scott Cooper; John Thorson [75%]; Kim Yoshida; Johnathan Perrera | 600h | 600h | 9,984 | 9,984 | 9,984 |  |  |
| 5 | 1.4 | Scout locations |  | 1.38w | 2021-05-23 A | 2021-06-01 A | 4 | 100% |  | 2021-05-23 | 2021-06-04 | 1.38w | 2021-05-23 | 2021-06-04 |  |  |  |  | Jo Brown; Jan Miksovsky; 16 mm Film [2160 Feet]; Megan’s 16 mm camera; Max Benson | 213.33h | 213.33h | 3,712 | 3,712 | 3,712 |  |  |
| 6 | 1.5 | Select locations |  | 2.05w | 2021-06-04 A | 2021-06-18 A | 5 | 100% |  | 2021-06-04 | 2021-06-18 | 2.05w | 2021-06-04 | 2021-06-18 |  |  |  |  | Scott Cooper; Clair Hector; Max Benson | 240h | 240h | 5,070 | 5,070 | 5,070 |  |  |
| 7 | 1.6 | Hold auditions |  | 1w | 2021-06-15 A | 2021-06-21 A | 6 | 100% |  | 2021-06-18 | 2021-06-25 | 1w | 2021-06-18 | 2021-06-25 |  |  |  |  | Clair Hector; Scott Cooper; Doug Hampton [50%]; John Thorson [75%] | 130h | 130h | 2,300 | 2,240 | 2,300 |  |  |
| 8 | 1.7 | Apply for filming permits |  | 7d | 2021-06-19 A | 2021-06-28 A | 7FS-5% | 100% |  | 2021-06-20 | 2021-06-27 | 1w | 2021-06-20 | 2021-06-27 |  |  |  |  | Kim Yoshida | 56h | 56h | 1,026.4 | 876 | 1,026.4 |  |  |
| 9 | 1.8 | Reserve camera equipment |  | 0.5w | 2021-06-28 A | 2021-06-30 A | 8 | 100% |  | 2021-06-27 | 2021-07-02 | 0.5w | 2021-06-27 | 2021-07-02 |  |  |  |  | Jan Miksovsky; Eric Lang | 40h | 40h | 685 | 685 | 685 |  |  |
| 10 | 1.9 | Reserve sound equipment |  | 8d | 2021-06-28 A | 2021-07-07 A | 9SS | 100% |  | 2021-06-27 | 2021-07-04 | 4.8d | 2021-06-27 | 2021-07-04 |  |  |  |  | Peter Kelly; Eric Lang | 65.58h | 65.58h | 1,041.41 | 645 | 1,041.41 |  |  |
| 11 | 1.10 | Pre-Production complete! | milestone | 0d | 2021-07-10 A | 2021-07-10 A | 10 | 100% |  | 2021-07-04 | 2021-07-04 | 0d | 2021-07-04 | 2021-07-04 |  |  | 2001-07-13 |  |  |  |  |  |  |  |  |  |
| 12 | 1.11 | **Staff planning meeting** |  | 45.25d | 2021-04-06 A | 2021-06-08 A |  | 100% |  | 2021-04-06 | 2021-06-08 | 45.25d | 2021-04-06 | 2021-06-08 |  |  |  |  |  | 100h | 100h | 1,790.5 | 1,790.5 | 1,790.5 |  |  |
| 13 | 1.11.1 | Staff planning meeting 1 |  | 2h | 2021-04-06 A | 2021-04-06 A |  | 100% |  | 2021-04-06 | 2021-04-06 | 2h | 2021-04-06 | 2021-04-06 |  | start no earlier than 2001-04-06 |  |  | Clair Hector; Jo Brown; Johnathan Perrera; Kim Yoshida; Scott Cooper | 10h | 10h | 179.05 | 179.05 | 179.05 |  |  |
| 14 | 1.11.2 | Staff planning meeting 2 |  | 2h | 2021-04-13 A | 2021-04-13 A |  | 100% |  | 2021-04-13 | 2021-04-13 | 2h | 2021-04-13 | 2021-04-13 |  | start no earlier than 2001-04-13 |  |  | Clair Hector; Jo Brown; Johnathan Perrera; Kim Yoshida; Scott Cooper | 10h | 10h | 179.05 | 179.05 | 179.05 |  |  |
| 15 | 1.11.3 | Staff planning meeting 3 |  | 2h | 2021-04-20 A | 2021-04-20 A |  | 100% |  | 2021-04-20 | 2021-04-20 | 2h | 2021-04-20 | 2021-04-20 |  | start no earlier than 2001-04-20 |  |  | Clair Hector; Jo Brown; Johnathan Perrera; Kim Yoshida; Scott Cooper | 10h | 10h | 179.05 | 179.05 | 179.05 |  |  |
| 16 | 1.11.4 | Staff planning meeting 4 |  | 2h | 2021-04-27 A | 2021-04-27 A |  | 100% |  | 2021-04-27 | 2021-04-27 | 2h | 2021-04-27 | 2021-04-27 |  | start no earlier than 2001-04-27 |  |  | Clair Hector; Jo Brown; Johnathan Perrera; Kim Yoshida; Scott Cooper | 10h | 10h | 179.05 | 179.05 | 179.05 |  |  |
| 17 | 1.11.5 | Staff planning meeting 5 |  | 2h | 2021-05-04 A | 2021-05-04 A |  | 100% |  | 2021-05-04 | 2021-05-04 | 2h | 2021-05-04 | 2021-05-04 |  | start no earlier than 2001-05-04 |  |  | Clair Hector; Jo Brown; Johnathan Perrera; Kim Yoshida; Scott Cooper | 10h | 10h | 179.05 | 179.05 | 179.05 |  |  |
| 18 | 1.11.6 | Staff planning meeting 6 |  | 2h | 2021-05-11 A | 2021-05-11 A |  | 100% |  | 2021-05-11 | 2021-05-11 | 2h | 2021-05-11 | 2021-05-11 |  | start no earlier than 2001-05-11 |  |  | Clair Hector; Jo Brown; Johnathan Perrera; Kim Yoshida; Scott Cooper | 10h | 10h | 179.05 | 179.05 | 179.05 |  |  |
| 19 | 1.11.7 | Staff planning meeting 7 |  | 2h | 2021-05-18 A | 2021-05-18 A |  | 100% |  | 2021-05-18 | 2021-05-18 | 2h | 2021-05-18 | 2021-05-18 |  | start no earlier than 2001-05-18 |  |  | Clair Hector; Jo Brown; Johnathan Perrera; Kim Yoshida; Scott Cooper | 10h | 10h | 179.05 | 179.05 | 179.05 |  |  |
| 20 | 1.11.8 | Staff planning meeting 8 |  | 2h | 2021-05-25 A | 2021-05-25 A |  | 100% |  | 2021-05-25 | 2021-05-25 | 2h | 2021-05-25 | 2021-05-25 |  | start no earlier than 2001-05-25 |  |  | Clair Hector; Jo Brown; Johnathan Perrera; Kim Yoshida; Scott Cooper | 10h | 10h | 179.05 | 179.05 | 179.05 |  |  |
| 21 | 1.11.9 | Staff planning meeting 9 |  | 2h | 2021-06-01 A | 2021-06-01 A |  | 100% |  | 2021-06-01 | 2021-06-01 | 2h | 2021-06-01 | 2021-06-01 |  | start no earlier than 2001-06-01 |  |  | Clair Hector; Jo Brown; Johnathan Perrera; Kim Yoshida; Scott Cooper | 10h | 10h | 179.05 | 179.05 | 179.05 |  |  |
| 22 | 1.11.10 | Staff planning meeting 10 |  | 2h | 2021-06-08 A | 2021-06-08 A |  | 100% |  | 2021-06-08 | 2021-06-08 | 2h | 2021-06-08 | 2021-06-08 |  | start no earlier than 2001-06-08 |  |  | Clair Hector; Jo Brown; Johnathan Perrera; Kim Yoshida; Scott Cooper | 10h | 10h | 179.05 | 179.05 | 179.05 |  |  |
| 23 | 2 | **Production** |  | 52d | 2021-07-10 A | 2021-09-21 | 1 | 57% | 22.14d | 2021-07-04 | 2021-09-05 | 45.39d | 2021-07-04 | 2021-09-05 | 0d |  | 2021-09-28 |  |  | 2439h | 1346h | 51,932.62 | 44,425.38 | 29,451.38 |  |  |
| 24 | 2.1 | **Scene 7** |  | 5d | 2021-07-10 A | 2021-07-17 A |  | 100% |  | 2021-07-04 | 2021-07-10 | 3.75d | 2021-07-04 | 2021-07-10 |  |  |  |  |  | 220h | 220h | 5,415.25 | 4,900 | 5,415.25 |  |  |
| 25 | 2.1.1 | Scene 7 setup |  | 0.92d | 2021-07-10 A | 2021-07-10 A |  | 100% |  | 2021-07-04 | 2021-07-05 | 1d | 2021-07-04 | 2021-07-05 |  |  |  |  | Jo Brown [116.7%]; Max Benson [116.7%]; Electrician [420%]; Peter Kelly [58.3%] | 46h | 46h | 981 | 497 | 981 |  |  |
| 26 | 2.1.2 | Scene 7 rehearsal |  | 12.67h | 2021-07-11 A | 2021-07-12 A | 25 | 100% |  | 2021-07-05 | 2021-07-06 | 8h | 2021-07-05 | 2021-07-06 |  |  |  |  | Scott Cooper [68.8%]; Jo Brown [64.3%]; Paul Born [37.5%]; Joseph Matthews [87.5%]; Sue Jackson [85.7%]; Jan Miksovsky [64.3%] | 46.5h | 46.5h | 736.25 | 705 | 736.25 |  |  |
| 27 | 2.1.3 | Scene 7 shoot |  | 6h | 2021-07-13 A | 2021-07-13 A | 26 | 100% |  | 2021-07-06 | 2021-07-09 | 6h | 2021-07-06 | 2021-07-09 |  |  |  |  | Scott Cooper; Jo Brown; Paul Born [50%]; Joseph Matthews; Sue Jackson; Frank Lee; John Thorson [75%]; Keith Harris; Ted Bremer; 16 mm Camera [300%]; 5000 Watt Light [200%]; 16 mm Film [1620 Feet]; Joshua Randall; Megan Sherman; Tim O'Brien; Jan Miksovsky | 103.5h | 103.5h | 3,201 | 3,201 | 3,201 | Richard, Store clerk #1, Store clerk #2 | Grocery store |
| 28 | 2.1.4 | Scene 7 teardown |  | 1d | 2021-07-16 A | 2021-07-16 A | 27 | 100% |  | 2021-07-09 | 2021-07-10 | 1d | 2021-07-09 | 2021-07-10 |  |  |  |  | Jo Brown; Max Benson; Electrician [50%]; Peter Kelly [50%] | 24h | 24h | 497 | 497 | 497 |  |  |
| 29 | 2.1.5 | Scene 7-process dailies |  | 1d | 2021-07-16 A | 2021-07-17 A | 27 | 100% |  | 2021-07-09 | 2021-07-10 | 1d | 2021-07-09 | 2021-07-10 |  |  |  | Night Shift |  |  |  |  |  |  |  |  |

Notes:
- 25: Had signifigant problems getting wiring set up properly; authorized overtime work by electricians.

| ID | WBS | Task | Duration | Start | Finish | Predecessors | Complete | Baseline start | Baseline finish | Baseline duration | Baseline 1 start | Baseline 1 finish | Constraint | Calendar | Resources | Work | Actual work | Cost | Baseline cost | Actual cost | Cast | Location |
| --- | --- | --- | --- | --- | --- | --- | --- | --- | --- | --- | --- | --- | --- | --- | --- | --- | --- | --- | --- | --- | --- | --- |
| 30 | 2.2 | **Scene 3** | 6d | 2021-07-17 A | 2021-07-27 A | 24 | 100% | 2021-07-10 | 2021-07-18 | 6d | 2021-07-10 | 2021-07-18 |  |  |  | 332h | 332h | 6,615.5 | 5,179 | 6,615.5 |  |  |
| 31 | 2.2.1 | Scene 3 setup | 3.25d | 2021-07-17 A | 2021-07-21 A |  | 100% | 2021-07-10 | 2021-07-11 | 1d | 2021-07-10 | 2021-07-11 | start no earlier than 2001-07-05 |  | Jo Brown; Max Benson; Electrician | 78h | 78h | 1,683.5 | 518 | 1,683.5 |  |  |
| 32 | 2.2.2 | Scene 3 rehearsal | 1d | 2021-07-23 A | 2021-07-23 A | 31 | 100% | 2021-07-11 | 2021-07-16 | 1.36d | 2021-07-11 | 2021-07-16 |  |  | Scott Cooper; Jo Brown; Eric Miller; Jim Hance; Anne L. Paper; Joseph Matthews; Jan Miksovsky | 56h | 56h | 755 | 755 | 755 |  |  |
| 33 | 2.2.3 | Scene 3 shoot | 8h | 2021-07-24 A | 2021-07-24 A | 32 | 100% | 2021-07-16 | 2021-07-17 | 8h | 2021-07-16 | 2021-07-17 |  |  | Scott Cooper; Jo Brown; Eric Miller; Jim Hance; Anne L. Paper; Joseph Matthews; Tim O'Brien; Megan Sherman; John Thorson [75%]; Doug Hampton [50%]; Keith Harris; 16 mm Camera [200%]; 5000 Watt Light [400%]; Dolly; 16 mm Film [1080 Feet]; Frank Lee; Jan Miksovsky; Ted Bremer | 162h | 162h | 3,400 | 3,388 | 3,400 | Man on street, Richard | Street corner |
| 34 | 2.2.4 | Scene 3 teardown | 1.5d | 2021-07-25 A | 2021-07-26 A | 33 | 100% | 2021-07-17 | 2021-07-18 | 1d | 2021-07-17 | 2021-07-18 |  |  | Jo Brown; Max Benson; Electrician | 36h | 36h | 777 | 518 | 777 |  |  |
| 35 | 2.2.5 | Scene 3-process dailies | 1d | 2021-07-24 A | 2021-07-27 A | 33 | 100% | 2021-07-17 | 2021-07-18 | 1d | 2021-07-17 | 2021-07-18 |  | Night Shift |  |  |  |  |  |  |  |  |
| 36 | 2.3 | **Scene 1** | 11.5d | 2021-07-26 A | 2021-08-10 A | 30 | 100% | 2021-07-18 | 2021-07-26 | 5.75d | 2021-07-18 | 2021-07-26 |  |  |  | 392.5h | 392.5h | 9,194.25 | 6,756.25 | 9,194.25 |  |  |
| 37 | 2.3.1 | Scene 1 setup | 5d | 2021-07-26 A | 2021-07-30 A |  | 100% | 2021-07-18 | 2021-07-23 | 3d | 2021-07-18 | 2021-07-23 |  |  | Jo Brown; Max Benson; Electrician [200%] | 160h | 160h | 3,470 | 2,082 | 3,470 |  |  |
| 38 | 2.3.2 | Scene 1 rehearsal | 1d | 2021-08-02 A | 2021-08-02 A | 37 | 100% | 2021-07-23 | 2021-07-24 | 1d | 2021-07-23 | 2021-07-24 |  |  | Scott Cooper; Jo Brown; Paul Born [50%]; David Campbell; Eric Miller; Sue Jackson; Jan Miksovsky | 52h | 52h | 780 | 780 | 780 |  |  |
| 39 | 2.3.3 | Scene 1 shoot | 6h | 2021-08-03 A | 2021-08-03 A | 38 | 100% | 2021-07-24 | 2021-07-25 | 6h | 2021-07-24 | 2021-07-25 |  |  | Scott Cooper; Jo Brown; Paul Born [50%]; David Campbell; Eric Miller; Sue Jackson; Tim O'Brien; Frank Lee; Megan Sherman; John Thorson [75%]; Doug Hampton [50%]; Keith Harris; Ted Bremer; 16 mm Camera [300%]; 5000 Watt Light; 16 mm Film [1620 Feet]; Jan Miksovsky | 100.5h | 100.5h | 3,209.25 | 3,200.25 | 3,209.25 | Garth, Man on street, Store clerk #1 | Street corner |
| 40 | 2.3.4 | Scene 1 teardown | 2.5d | 2021-08-06 A | 2021-08-10 A | 39 | 100% | 2021-07-25 | 2021-07-26 | 1d | 2021-07-25 | 2021-07-26 |  |  | Jo Brown; Max Benson; Electrician [200%] | 80h | 80h | 1,735 | 694 | 1,735 |  |  |
| 41 | 2.3.5 | Scene 1-process dailies | 1d | 2021-08-06 A | 2021-08-07 A | 39 | 100% | 2021-07-25 | 2021-07-26 | 1d | 2021-07-25 | 2021-07-26 |  | Night Shift |  |  |  |  |  |  |  |  |
| 42 | 2.4 | **Scene 2** | 4.5d | 2021-08-08 A | 2021-08-13 A | 36 | 100% | 2021-07-26 | 2021-07-30 | 2.39d | 2021-07-26 | 2021-07-30 |  |  |  | 103.5h | 103.5h | 2,223.38 | 2,209.88 | 2,223.38 |  |  |
| 43 | 2.4.1 | Scene 2 setup | 1d | 2021-08-08 A | 2021-08-08 A |  | 100% | 2021-07-26 | 2021-07-27 | 1d | 2021-07-26 | 2021-07-27 |  |  | Jo Brown; Max Benson; Electrician | 24h | 24h | 518 | 518 | 518 |  |  |
| 44 | 2.4.2 | Scene 2 rehearsal | 6h | 2021-08-09 A | 2021-08-09 A | 43 | 100% | 2021-07-27 | 2021-07-27 | 6h | 2021-07-27 | 2021-07-27 |  |  | Scott Cooper; Doug Hampton [50%]; David Campbell; Anne L. Paper; Jan Miksovsky | 27h | 27h | 380.25 | 371.25 | 380.25 |  |  |
| 45 | 2.4.3 | Scene 2 shoot | 3h | 2021-08-10 A | 2021-08-10 A | 44 | 100% | 2021-07-27 | 2021-07-27 | 3h | 2021-07-27 | 2021-07-27 |  | Evening Shoot | Scott Cooper; Doug Hampton [50%]; Anne L. Paper; Tim O'Brien; Frank Lee; Keith Harris; Ted Bremer; 16 mm Camera [200%]; 5000 Watt Light [300%]; 16 mm Film [1080 Feet]; Jan Miksovsky; David Campbell | 40.5h | 40.5h | 1,066.12 | 1,061.62 | 1,066.12 | Garth, Shelly | Shelly's living room |
| 46 | 2.4.4 | Scene 2 teardown | 0.5d | 2021-08-13 A | 2021-08-13 A | 45 | 100% | 2021-07-30 | 2021-07-30 | 0.5d | 2021-07-30 | 2021-07-30 |  |  | Jo Brown; Max Benson; Electrician | 12h | 12h | 259 | 259 | 259 |  |  |
| 47 | 2.4.5 | Scene 2-process dailies | 1d | 2021-08-10 A | 2021-08-11 A | 45 | 100% | 2021-07-27 | 2021-07-28 | 1d | 2021-07-27 | 2021-07-28 |  | Night Shift |  |  |  |  |  |  |  |  |
| 48 | 2.5 | **Scene 5** | 6d | 2021-08-13 A | 2021-08-20 A | 42 | 100% | 2021-07-30 | 2021-08-06 | 5.5d | 2021-07-30 | 2021-08-06 |  |  |  | 298h | 298h | 6,003 | 5,375 | 6,003 |  |  |
| 49 | 2.5.1 | Scene 5 setup | 2.5d | 2021-08-13 A | 2021-08-17 A |  | 100% | 2021-07-30 | 2021-08-01 | 2.5d | 2021-07-30 | 2021-08-01 |  |  | Jo Brown; Max Benson; Electrician | 60h | 60h | 1,295 | 855 | 1,295 |  |  |
| 50 | 2.5.2 | Scene 5 rehearsal | 1d | 2021-08-16 A | 2021-08-16 A | 49 | 100% | 2021-08-02 | 2021-08-02 | 1d | 2021-08-02 | 2021-08-02 |  |  | Scott Cooper; Jo Brown; Eric Miller; David Campbell; Sue Jackson; Daniel Penn; Anne L. Paper; Jan Miksovsky [50%] | 60h | 60h | 755 | 755 | 755 |  |  |
| 51 | 2.5.3 | Scene 5 shoot | 8h | 2021-08-17 A | 2021-08-17 A | 50 | 100% | 2021-08-03 | 2021-08-03 | 8h | 2021-08-03 | 2021-08-03 |  |  | Scott Cooper; Jo Brown; Eric Miller; David Campbell; Sue Jackson; Daniel Penn; Anne L. Paper; Tim O'Brien; Frank Lee; Megan Sherman; John Thorson [75%]; Doug Hampton [50%]; Keith Harris; Ted Bremer; 16 mm Camera [200%]; 5000 Watt Light [200%]; Crane; 16 mm Film [1080 Feet]; Jan Miksovsky | 154h | 154h | 3,435 | 3,423 | 3,435 | Man on street, Garth, Old man, Shelly | Street corner |
| 52 | 2.5.4 | Scene 5 teardown | 1d | 2021-08-20 A | 2021-08-20 A | 51 | 100% | 2021-08-06 | 2021-08-06 | 1d | 2021-08-06 | 2021-08-06 |  |  | Jo Brown; Max Benson; Electrician | 24h | 24h | 518 | 342 | 518 |  |  |
| 53 | 2.5.5 | Scene 5-process dailies | 1d | 2021-08-17 A | 2021-08-18 A | 51 | 100% | 2021-08-03 | 2021-08-04 | 1d | 2021-08-03 | 2021-08-04 |  | Night Shift |  |  |  |  |  |  |  |  |

Notes:
- 31: This scene must be shot no earlier than July 5 due to limited access to site

| ID | WBS | Task | Duration | Start | Finish | Predecessors | Baseline start | Baseline finish | Baseline duration | Baseline 1 start | Baseline 1 finish | Total slack | Free slack | Calendar | Resources | Work | Cost | Baseline cost | Cast | Location |
| --- | --- | --- | --- | --- | --- | --- | --- | --- | --- | --- | --- | --- | --- | --- | --- | --- | --- | --- | --- | --- |
| 54 | 2.6 | **Scene 6** | 12.5d | 2021-08-23 | 2021-09-08 | 48 | 2021-08-07 | 2021-08-23 | 12.5d | 2021-08-07 | 2021-08-23 | 0.5d | 0d |  |  | 628h | 13,184 | 11,588 |  |  |
| 55 | 2.6.1 | Scene 6 setup | 6d | 2021-08-23 | 2021-08-30 |  | 2021-08-07 | 2021-08-14 | 6d | 2021-08-07 | 2021-08-14 | 0.5d | 0d |  | Jo Brown; Max Benson; Electrician | 144h | 3,108 | 2,052 |  |  |
| 56 | 2.6.2 | Scene 6 rehearsal | 2d | 2021-08-31 | 2021-09-01 | 55 | 2021-08-15 | 2021-08-16 | 2d | 2021-08-15 | 2021-08-16 | 0.5d | 0d |  | Scott Cooper; Jo Brown; Doug Hampton [50%]; Paul Born [50%]; David Campbell; Sue Jackson; Anne L. Paper; Jim Hance; Daniel Penn; Jan Miksovsky [50%] | 136h | 1,814 | 1,802 |  |  |
| 57 | 2.6.3 | Scene 6 shoot | 12h | 2021-09-02 | 2021-09-03 | 56 | 2021-08-17 | 2021-08-20 | 12h | 2021-08-17 | 2021-08-20 | 0.5d | 0d |  | Scott Cooper; Jo Brown; Doug Hampton [50%]; Paul Born [50%]; David Campbell; Sue Jackson; Anne L. Paper; Jim Hance; Daniel Penn; Frank Lee; Megan Sherman; Keith Harris; Ted Bremer; 16 mm Camera [300%]; 5000 Watt Light [300%]; Dolly; Crane; 16 mm Film [1620 Feet]; Joshua Randall; Tim O'Brien; Jan Miksovsky | 276h | 6,708 | 6,708 | Garth, Store Clerk #1, Shelly, Old man | Grocery store |
| 58 | 2.6.4 | Scene 6 teardown | 3d | 2021-09-03 | 2021-09-08 | 57 | 2021-08-20 | 2021-08-23 | 3d | 2021-08-20 | 2021-08-23 | 0.5d |  |  | Jo Brown; Max Benson; Electrician | 72h | 1,554 | 1,026 |  |  |
| 59 | 2.6.5 | Scene 6-process dailies | 1d | 2021-09-03 | 2021-09-04 | 57 | 2021-08-20 | 2021-08-21 | 1d | 2021-08-20 | 2021-08-21 | 3d |  | Night Shift |  |  |  |  |  |  |
| 60 | 2.7 | **Scene 8** | 6.5d | 2021-09-08 | 2021-09-16 | 54 | 2021-08-23 | 2021-08-31 | 6.5d | 2021-08-23 | 2021-08-31 | 0.5d | 0d |  |  | 360h | 7,063.5 | 6,535.5 |  |  |
| 61 | 2.7.1 | Scene 8 setup | 2d | 2021-09-08 | 2021-09-10 |  | 2021-08-23 | 2021-08-27 | 2d | 2021-08-23 | 2021-08-27 | 0.5d | 0d |  | Jo Brown; Max Benson; Peter Kelly; Electrician | 64h | 1,304 | 952 |  |  |
| 62 | 2.7.2 | Scene 8 rehearsal | 2.5d | 2021-09-10 | 2021-09-14 | 61 | 2021-08-27 | 2021-08-29 | 2.5d | 2021-08-27 | 2021-08-29 | 0.5d | 0d |  | Scott Cooper; Jo Brown; Doug Hampton [50%]; Paul Born [50%]; David Campbell; Sue Jackson; Eric Miller; Jan Miksovsky [50%] | 130h | 1,892.5 | 1,892.5 |  |  |
| 63 | 2.7.3 | Scene 8 shoot | 8h | 2021-09-15 | 2021-09-15 | 62 | 2021-08-30 | 2021-08-30 | 8h | 2021-08-30 | 2021-08-30 | 0.5d | 0d |  | Scott Cooper; Jo Brown; Doug Hampton [50%]; Paul Born [50%]; David Campbell; Sue Jackson; Eric Miller; Tim O'Brien; Jan Miksovsky; Megan Sherman; John Thorson [75%]; Keith Harris; Ted Bremer; 16 mm Camera [200%]; 5000 Watt Light; Dolly [200%]; 16 mm Film [1080 Feet] | 134h | 3,215 | 3,215 | Garth, Store clerk #1, Man on street | Street corner |
| 64 | 2.7.4 | Scene 8 teardown | 1d | 2021-09-16 | 2021-09-16 | 63 | 2021-08-31 | 2021-08-31 | 1d | 2021-08-31 | 2021-08-31 | 0.5d |  |  | Jo Brown; Max Benson; Peter Kelly; Electrician | 32h | 652 | 476 |  |  |
| 65 | 2.7.5 | Scene 8-process dailies | 1d | 2021-09-15 | 2021-09-16 | 63 | 2021-08-30 | 2021-08-31 | 1d | 2021-08-30 | 2021-08-31 | 1d |  | Night Shift |  |  |  |  |  |  |
| 66 | 2.8 | **Scene 4** | 3d | 2021-09-17 | 2021-09-21 | 60 | 2021-09-03 | 2021-09-05 | 3d | 2021-09-03 | 2021-09-05 | 0d |  |  |  | 105h | 2,233.75 | 1,881.75 |  |  |
| 67 | 2.8.1 | Scene 4 setup | 1d | 2021-09-17 | 2021-09-17 |  | 2021-09-03 | 2021-09-03 | 1d | 2021-09-03 | 2021-09-03 | 0.5d | 0d |  | Jo Brown; Max Benson; Peter Kelly; Electrician | 32h | 652 | 476 |  |  |
| 68 | 2.8.2 | Scene 4 rehearsal | 4h | 2021-09-20 | 2021-09-20 | 67 | 2021-09-04 | 2021-09-04 | 4h | 2021-09-04 | 2021-09-04 | 0.5d |  |  | Scott Cooper; Doug Hampton [50%]; Anne L. Paper; Joseph Matthews; Jan Miksovsky [50%] | 16h | 216 | 216 |  |  |
| 69 | 2.8.3 | Scene 4 shoot | 2h | 2021-09-20 | 2021-09-20 | 68 | 2021-09-04 | 2021-09-04 | 2h | 2021-09-04 | 2021-09-04 | 0.38d | 0.25d | Evening Shoot | Scott Cooper; Doug Hampton [50%]; Anne L. Paper; Joseph Matthews; Frank Lee; Megan Sherman; Keith Harris; 16 mm Camera [200%]; 5000 Watt Light [200%]; 16 mm Film [1080 Feet]; Jan Miksovsky; Ted Bremer | 25h | 713.75 | 713.75 | Shelly, Richard | Elevator |
| 70 | 2.8.4 | Scene 4 teardown | 1d | 2021-09-21 | 2021-09-21 | 69 | 2021-09-05 | 2021-09-05 | 1d | 2021-09-05 | 2021-09-05 | 0d |  |  | Jo Brown; Max Benson; Peter Kelly; Electrician | 32h | 652 | 476 |  |  |
| 71 | 2.8.5 | Scene 4-process dailies | 1d | 2021-09-20 | 2021-09-21 | 69 | 2021-09-04 | 2021-09-05 | 1d | 2021-09-04 | 2021-09-05 | 1d |  | Night Shift |  |  |  |  |  |  |
| 72 | 3 | **Post-Production** | 70.32d | 2021-09-22 | 2021-12-29 | 23 | 2021-09-06 | 2021-12-20 | 73.42d | 2021-09-06 | 2021-12-20 | 0d |  |  |  | 1737.43h | 28,256.02 | 27,816.02 |  |  |
| 73 | 3.1 | Log footage | 1.25w | 2021-09-22 | 2021-09-29 |  | 2021-09-06 | 2021-09-12 | 1.2w | 2021-09-06 | 2021-09-12 | 0d |  |  | Editing Lab; Florian Voss | 82h | 1,949 | 1,905 |  |  |
| 74 | 3.2 | Record rough narration | 8d | 2021-09-29 | 2021-10-08 | 73 | 2021-09-13 | 2021-09-24 | 8d | 2021-09-13 | 2021-09-24 | 0.15d | 0d |  | Peter Kelly; David Campbell; Michael Patten | 192h | 2,792 | 2,792 |  |  |
| 75 | 3.3 | Paper edit footage | 2w | 2021-10-11 | 2021-10-22 | 74 | 2021-09-25 | 2021-10-08 | 2w | 2021-09-25 | 2021-10-08 | 0.15d | 0d |  | Clair Hector; Kim Yoshida; Lisa Garmaise; Richard Lum | 320h | 4,322 | 4,322 |  |  |
| 76 | 3.4 | Rough cut edit | 1w | 2021-10-18 | 2021-10-22 | 75FS-5d | 2021-10-09 | 2021-10-15 | 1w | 2021-10-09 | 2021-10-15 | 0.15d | 0d |  | Clair Hector; Richard Lum | 80h | 1,425 | 1,425 |  |  |
| 77 | 3.5 | Fine cut edit | 2w | 2021-10-25 | 2021-11-05 | 76 | 2021-10-16 | 2021-10-29 | 2w | 2021-10-16 | 2021-10-29 | 0.15d | 0d |  | Clair Hector; Richard Lum; Lisa Garmaise; Kim Yoshida; Editing Lab | 400h | 6,347 | 6,347 |  |  |
| 78 | 3.6 | Hold formal approval showing | 1d | 2021-11-08 | 2021-11-08 | 77 | 2021-10-30 | 2021-10-30 | 1d | 2021-10-30 | 2021-10-30 | 0.15d | 0d |  | Clair Hector; Jan Miksovsky [50%]; Jo Brown; John Thorson [75%]; Doug Hampton [50%]; Mark Hassall; Scott Cooper; David Campbell [50%] | 50h | 912.5 | 912.5 |  |  |
| 79 | 3.7 | Record final narration | 3.33w | 2021-11-09 | 2021-12-01 | 78 | 2021-10-31 | 2021-11-26 | 3.33w | 2021-10-31 | 2021-11-26 | 0.15d | 0d |  | Peter Kelly; David Campbell; Michael Patten; Scott Cooper | 320h | 5,040 | 5,040 |  |  |
| 80 | 3.8 | Add head and tail titles | 0.64w | 2021-12-01 | 2021-12-06 | 79 | 2021-11-26 | 2021-11-29 | 0.64w | 2021-11-26 | 2021-11-29 | 0.15d | 0d |  | Jo Brown; John Thorson [75%]; Michael Patten; Editing Lab | 95.43h | 1,879.52 | 1,879.52 |  |  |
| 81 | 3.9 | Add final music | 1.64w | 2021-12-01 | 2021-12-13 | 80SS | 2021-11-26 | 2021-12-06 | 1.64w | 2021-11-26 | 2021-12-06 | 0.15d | 0d |  | Michael Patten; Peter Kelly | 80h | 1,370 | 1,370 |  |  |
| 82 | 3.10 | Print internegative of film | 5.25d | 2021-12-13 | 2021-12-21 | 81 | 2021-12-06 | 2021-12-12 | 3d | 2021-12-06 | 2021-12-12 | 0d |  |  | Florian Voss | 42h | 924 | 528 |  |  |
| 83 | 3.11 | Clone dubbing masters of audio tape | 4d | 2021-12-21 | 2021-12-24 | 82 | 2021-12-12 | 2021-12-18 | 4d | 2021-12-12 | 2021-12-18 | 0d |  |  | Peter Kelly; Doug Hampton [50%] | 48h | 744 | 744 |  |  |
| 84 | 3.12 | Archive master film and audio tape | 1.32d | 2021-12-27 | 2021-12-28 | 83 | 2021-12-18 | 2021-12-19 | 1.32d | 2021-12-18 | 2021-12-19 | 0d |  |  | Peter Kelly; Doug Hampton [50%]; Editing Lab | 20h | 411 | 411 |  |  |
| 85 | 3.13 | Hand off masters to distributor | 1d | 2021-12-28 | 2021-12-29 | 84 | 2021-12-19 | 2021-12-20 | 1d | 2021-12-19 | 2021-12-20 | 0d |  |  | Michael Patten | 8h | 140 | 140 |  |  |
